# 3GPP_Release-2000

Schedule from MS Project, 2000-01-03 to 2006-12-29, A marks actual dates.

## Calendars

- Standard: Mon-Fri 08:00-12:00, 13:00-17:00; Sat-Sun off. Exceptions (off unless hours are given): 2005-12-24 08:00-12:00, 13:00-17:00, 2006-12-24 08:00-12:00, 13:00-17:00.

## Resources

| Resource |
| --- |
| NP |
| N1 |
| N2 |
| N3 |
| N4 |
| N5 |
| TP |
| T1 |
| T2 |
| T3 |
| RP |
| R1 |
| R2 |
| R3 |
| R4 |
| SP |
| S1 |
| S2 |
| S3 |
| S4 |
| S5 |
| PCG |
| GP |
| No |
| CN4 |
| ? |
| WG G2 |
| G2 |
| G1 |
| G4 |
| G3 |
| All |
| Generic |
| MLST |
| G5 |
| S3; G2 |
| WG T2 |
| GP;G1 |
| G4;G5 |
| OMA |
| GP-G2 |
| Yes |
| GP; |
| N4; |
| GP; N1 |
| CT5 |
| C5 |
| C1 |
| C4 |
| C3 |
| C6 |

## Schedule

| ID | WBS | Task | Type | Duration | Start | Finish | Complete | Remaining | Baseline start | Baseline finish | Baseline duration | Total slack | Constraint | Resources | Work | Actual work | Text9 | Text6 | Text1 | Text3 | Text4 | Text5 | Text7 | Text8 | Text2 | Text12 |
| --- | --- | --- | --- | --- | --- | --- | --- | --- | --- | --- | --- | --- | --- | --- | --- | --- | --- | --- | --- | --- | --- | --- | --- | --- | --- | --- |
| 1 | 1 | VERSION 2005 June 23rd |  | 1d | 2000-01-03 | 2000-01-03 |  |  | 2000-01-03 | 2000-01-03 | 1d | 1824d |  |  |  |  | 2044 |  |  |  |  |  |  |  |  |  |
| 2 | 2 | "CTRL + a" to display all the 3GPP fields |  | 1d | 2000-01-03 | 2000-01-03 |  |  | 2000-01-03 | 2000-01-03 | 1d | 1824d |  |  |  |  | 1462 |  |  |  |  |  |  |  |  |  |
| 3 | 3 | Content of Release 7, not frozen |  | 1d | 2000-01-03 | 2000-01-03 |  |  | 2000-01-03 | 2000-01-03 | 1d | 1824d |  |  |  |  | 2058 |  |  |  |  |  |  |  |  |  |
| 5 | 4 | Rel-7 Features listed below |  | 1d? | 2000-01-03 | 2000-01-03 |  |  | 2000-01-03 | 2000-01-03 | 1d? | 1824d |  |  |  |  |  | Rel-7 |  |  |  |  |  |  |  |  |
| 6 | 8.5 | **Multiple Input Multiple Output antennas (MIMO)** |  | 719d? | 2003-03-14 A | 2005-12-15 | 12% | 634.49d? | 2003-03-14 | 2005-12-15 | 719d? | 274d |  | R1 | 23544h | 4190.4h | 2468 | Rel-7 | MIMO | TR25.876,TR25.996 | Howard Huang, Lucent | hchuang@lucent.com | TSG | Cesar |  |  |
| 7 | 5.1 | MIMO - Physical layer |  | 392d? | 2003-09-12 A | 2005-03-15 | 60% | 156.8d? | 2003-09-12 | 2005-03-15 | 392d? | 471d | finish no earlier than 2005-03-15 | R1 | 3136h | 1881.6h |  | Rel-7 | MIMO-Phys | 25.211, 25.212, 25.213, 25.214, 25.215, 25.221, 25 | Howard Huang, Lucent | hchuang@lucent.com | TSG | Cesar |  |  |
| 8 | 5.2 | MIMO - Layer 2,3 aspects |  | 589d? | 2003-09-12 | 2005-12-15 |  |  | 2003-09-12 | 2005-12-15 | 589d? | 274d | finish no earlier than 2005-12-15 | R2 | 4712h |  |  | Rel-7 | MIMO-L23 | TR 25.876 | Howard Huang, Lucent | hchuang@lucent.com | TSG | Cesar |  |  |
| 9 | 5.3 | MIMO - Iub/Iur Protocol Aspects |  | 719d? | 2003-03-14 | 2005-12-15 |  |  | 2003-03-14 | 2005-12-15 | 719d? | 274d | finish no earlier than 2005-12-15 | R3 | 5752h |  |  | Rel-7 | MIMO-IurIub |  | Howard Huang, Lucent | hchuang@lucent.com | TSG | Cesar |  |  |
| 10 | 5.4 | MIMO - RF Radio Transmission/Reception, System Performance Requirements and Conformance Testing |  | 524d? | 2003-12-12 A | 2005-12-15 | 5% | 497.8d? | 2003-12-12 | 2005-12-15 | 524d? | 274d | finish no earlier than 2005-12-15 | R4 | 4192h | 209.6h |  | Rel-7 | MIMO-RF |  | Man Hung Ng, Lucent | ngm@lucent.com | TSG | Cesar |  |  |
| 11 | 6 | **PS domain and IMS impacts for supporting IMS Emergency calls** |  | 1656d? | 2000-08-14 A | 2006-12-15 | 37% | 1040.43d? | 2000-08-14 | 2005-12-08 | 1389d? | 11d |  | S2 | 61112h | 18984.6h |  | Rel-7 | EMC1 |  | Rainer Liebhart |  | TSG | Maurice |  |  |
| 12 | 10.1.1 | Service Requirements for IP-based emergency calls |  | 985d | 2000-09-18 A | 2004-06-25 A | 100% |  | 2000-09-18 | 2004-06-25 | 985d |  | finish no earlier than 2004-06-25 | S1 | 7880h | 7880h | 1314 | Rel-7 | EMC1 | 22.976 |  |  |  |  | CCaR |  |
| 13 | 6.2 | Study on Stage 2 for IMS-level solution |  | 668d? | 2003-02-26 A | 2005-09-16 | 90% | 66.8d? | 2003-02-26 | 2005-09-16 | 668d? | 337d | finish no earlier than 2005-09-16 | S2 | 5344h | 4809.6h |  | Rel-7 | EMC1 | 23.228, 23.060, 23.002 | Rainer Liebhart, Siemenws |  | TSG |  |  |  |
| 14 | 6.3 | Study on Stage 2 for GPRS-level solution |  | 301d? | 2004-10-14 A | 2005-12-08 | 60% | 120.4d? | 2004-10-14 | 2005-12-08 | 301d? | 278d | finish no earlier than 2005-12-08 | S2 | 2408h | 1444.8h |  | Rel-7 | EMC1 |  |  |  |  |  |  |  |
| 15 | 6.4 | Stage 2 Specification Phase |  | 335d? | 2005-09-06 | 2006-12-15 |  |  | 2004-10-14 | 2005-12-08 | 301d? | 11d | finish no earlier than 2006-12-15 | S2 | 2680h |  |  | Rel-7 | EMC1 |  |  |  |  |  |  |  |
| 17 | 10.1 | **Emergency Call Enhancements for IP& PS Based Calls – stage 3** |  | 1280.1d | 2000-08-14 A | 2005-07-11 |  | 1280.1d | 2000-08-14 | 2005-07-11 | 1280.1d | 386.9d |  | C1 | 29752h |  | 1653 | Rel-7 | EMC1 |  | Mr Atle Monrad, Ericsson | Atle.Monrad@eto.ericsson.se |  |  | CCaR |  |
| 18 | 10.1.2 | IMS aspects to support IMS Emergency sessions |  | 1209d | 2000-10-17 A | 2005-07-08 |  | 1209d | 2000-10-17 | 2005-07-08 | 1209d | 387.82d | finish no earlier than 2005-06-03 | C1 | 9672h |  | 1315 | Rel-7 | EMC1 | 24.229 | Mr Atle Monrad, Ericsson | Atle.Monrad@eto.ericsson.se |  |  | CCaR |  |
| 19 | 10.1.5 | PS domain aspects to support IMS Emergency sessions |  | 1255d | 2000-08-14 A | 2005-07-11 |  | 1255d | 2000-08-14 | 2005-07-11 | 1255d | 386.9d | finish no earlier than 2005-06-03 | C1 | 10040h |  | 1646 | Rel-7 | EMC1 | 24.008 | Mr Atle Monrad, Ericsson | Atle.Monrad@eto.ericsson.se |  |  | CCaR |  |
| 20 | 7 | **Access Class Barring and Overload Protection** |  | 274d? | 2004-03-15 A | 2005-03-31 | 80% | 53.68d? | 2004-03-15 | 2005-03-31 | 274d? | 458d |  | S2 | 4928h | 3962.57h |  | Rel-7 | ACBOP | 23.898 | Chris Pudney, Vodafone |  | TSG | Maurice |  |  |
| 21 | 7.1 | TR on Stage 2 |  | 274d? | 2004-03-15 A | 2005-03-31 A | 100% |  | 2004-03-15 | 2005-03-31 | 274d? |  | finish no earlier than 2005-03-31 | S2 | 2192h | 2192h |  | Rel-7 | ACBOP |  |  |  | TSG |  |  |  |
| 22 | 7.2 | Extra ACBOP information in GERAN |  | 67d? | 2004-03-15 | 2004-06-15 |  |  | 2004-03-15 | 2004-06-15 | 67d? | 665d | start no earlier than 2004-03-15 | GP | 536h |  |  | Rel-7 | ACBOP | 44.018 |  |  | TSG |  |  |  |
| 23 | 7.3 | Stage 3 CN aspects of ACBOP |  | 1d? | 2004-12-08 A | 2004-12-08 A | 100% |  | 2004-12-08 | 2004-12-08 | 1d? |  | finish no earlier than 2004-12-08 | C1 | 8h | 8h |  | Rel-7 | ACBOP |  |  |  |  |  |  |  |
| 24 | 7.4 | Deleted - Potential impact on Iu interface Overload functionality | milestone | 0d? | 2004-03-15 A | 2004-03-15 A | 100% |  | 2004-03-15 | 2004-03-15 | 0d? |  | finish no earlier than 2004-03-15 | RP |  |  |  | Rel-7 | ACBOP | 25.413 |  |  |  |  |  | RP-25 |
| 25 | 7.5 | Deleted - Extra ACBOP information in RAN | milestone | 0d? | 2004-03-15 A | 2004-03-15 A | 100% |  | 2004-03-15 | 2004-03-15 | 0d? |  | finish no earlier than 2004-03-15 | RP |  |  |  | Rel-7 | ACBOP | 25.331 |  |  |  |  |  | RP-25 |
| 26 | 8 | **USSD message delivery and transfer to USIM** |  | 443.7d? | 2004-03-05 A | 2005-11-16 | 29% | 313.06d? | 2004-03-05 | 2005-11-16 | 443.7d? | 294.3d |  | S1 | 6781.6h | 1996.71h |  | Rel-7 | USSD-USIM | 22.090 |  |  | TSG | Michael |  |  |
| 27 | 8.1 | Stage 1 |  | 152d? | 2004-03-18 A | 2004-10-15 | 80% | 30.4d? | 2004-03-18 | 2004-10-15 | 152d? | 577d | start no earlier than 2004-03-18 | S1 | 1216h | 972.8h |  | Rel-7 | USSD-USIM | 22.090 |  |  | TSG | Michael |  |  |
| 28 | 8.2 | Alignment with requirements regarding USSD usage |  | 261d? | 2004-03-05 A | 2005-11-16 |  | 261d? | 2004-03-05 | 2005-11-16 | 261d? | 294.3d | finish no earlier than 2005-03-04 | C6 | 2088h |  |  | Rel-7 | USSD-USIM |  | Christophe Dubois (Axalto) | cdubois@axalto.com | TSG |  |  |  |

Notes:
- 23: NEW - inserted on 2/9/2004

| ID | WBS | Task | Type | Duration | Start | Finish | Complete | Remaining | Baseline start | Baseline finish | Baseline duration | Total slack | Constraint | Resources | Work | Actual work | Text1 | Text3 | Text6 | Text8 | Text4 | Text5 | Text7 |
| --- | --- | --- | --- | --- | --- | --- | --- | --- | --- | --- | --- | --- | --- | --- | --- | --- | --- | --- | --- | --- | --- | --- | --- |
| 29 | 9 | **Location Services enhancements Rel-7** |  | 514d? | 2004-06-28 A | 2006-06-15 | 38% | 317.37d? | 2004-06-28 | 2006-06-15 | 513d? | 143d |  | S2 | 22373.6h | 7528.38h | LCS3 | 23.271 | Rel-7 | Maurice |  |  |  |
| 30 | 9.1 | Global Stage 2 for LCS3 |  | 321d? | 2004-12-31 A | 2006-03-24 | 40% | 192.6d? | 2004-12-31 | 2006-03-24 | 321d? | 201d | finish no earlier than 2006-03-24 | S2 | 2568h | 1027.2h | LCS3 | 23.271 | Rel-7 | Maurice | Ben Rodilitz, SiRF | brodilitz@sirf.com | TSG |
| 31 | 9.2 | **LCS for 3GPP Interworking WLAN** |  | 329d? | 2004-06-28 A | 2005-09-29 | 65% | 115.15d? | 2004-06-28 | 2005-09-29 | 329d? | 328d |  | S1 | 5165.6h | 1745.24h | LCS3-IWLAN | 22.935 | Rel-7 | Michael | Mike Loushine, (Telcordia) |  | TSG |
| 32 | 9.2.1 | FS on 3GPP system to WLAN Interworking with LCS |  | 316.7d? | 2004-06-28 A | 2005-09-29 | 65% | 110.84d? | 2004-06-28 | 2005-09-29 | 316.7d? | 328d | finish no earlier than 2005-09-29 | S1 | 2533.6h | 1646.84h | LCS3-IWLAN | 22.935 | Rel-7 |  |  |  |  |
| 33 | 9.3 | **UE positioning Rel-7** |  | 457d? | 2004-09-15 A | 2006-06-15 | 35% | 297.43d? | 2004-09-15 | 2006-06-15 | 456d? | 143d |  | RP | 8880h | 3100.52h | LCS3-UEpos |  | Rel-7 | Cesar |  |  | TSG |
| 34 | 9.3.1 | Inclusion of Uplink TDOA UE positioning method in the UTRAN specifications |  | 456d? | 2004-09-15 A | 2006-06-15 | 50% | 228d? | 2004-09-15 | 2006-06-15 | 456d? | 143d | finish no earlier than 2006-06-15 | R2 | 3648h | 1824h | LCS3-UEPos-UTDOA | TS25.305, TS25.453 | Rel-7 | Cesar | Robert Gross, TruePosition | rlgross@trueposition.com | TSG |
| 35 | 9.3.2 | NEW!! LCS Enhancements Related to Location-Based Services |  | 197d? | 2005-03-15 | 2005-12-15 |  |  | 2005-03-15 | 2005-12-15 | 197d? | 274d | finish no earlier than 2005-12-15 | R2 | 1576h |  | LCS3-UEPos-Velocity | 25.305, 25.331, 25.410, 25.413, 25.453 | Rel-7 | Cesar | Ben Rodilitz | BRodilitz@SiRF.com | TSG |
| 36 | 9.4 | LCS Enhancements Related to Location-Based Services |  | 206d? | 2005-01-28 A | 2005-11-11 | 5% | 195.7d? | 2005-01-28 | 2005-11-11 | 206d? | 297d | finish no earlier than 2005-11-11 | GP | 1648h | 82.4h | LCS3-LBS | 43.059, 44.031, 48.008, 49.031 | Rel-7 | Paolo | Kevin Judge, SiRF Technologies | kjudge@sirf.com | TSG |
| 37 | 10 | **Deleted: FS on applicability of GALILEO for LCS** |  | 484d? | 2003-08-25 A | 2005-06-30 |  | 484d? | 2003-08-25 | 2005-06-30 | 484d? | 393d |  | S2 | 3872h | 1000h | Galileo |  | Rel-7 |  |  |  |  |
| 38 | 10.1 | Deleted - TR on Stage 2 | milestone | 0d? | 2005-06-30 A | 2005-06-30 A | 100% |  | 2005-06-30 | 2005-06-30 | 0d? |  | finish no earlier than 2005-06-30 | S2 |  |  | Galileo |  | Rel-7 |  |  |  |  |
| 39 | 10.2 | deleted - GERAN review of the TR | milestone | 0d? | 2003-08-25 | 2003-08-25 |  |  | 2003-08-25 | 2003-08-25 | 0d? | 877d | finish no earlier than 2003-08-25 | GP |  |  | Galileo |  | Rel-7 |  |  |  |  |
| 40 | 11 | **Selective Disabling of UE Capabilities** |  | 490.36d? | 2005-01-24 A | 2006-12-08 | 26% | 361.36d? | 2005-01-24 | 2006-12-08 | 489.36d? | 16d |  | S1 | 8316.8h | 2187.88h | SDoUE | 22.xxx | Rel-7 | Michael | Nigel Barnes (Motorola Ltd) | Nigel.Barnes@motorola.com | TSG |
| 41 | 11.1 | Stage 1 |  | 393.6d? | 2005-01-24 A | 2006-12-08 | 22% | 307.01d? | 2005-01-24 | 2006-12-08 | 393.6d? | 16d | finish no earlier than 2006-12-08 | S1 | 3148.8h | 692.74h | SDoUE-CRs | 22.101 | Rel-7 | Michael | Nigel Barnes (Motorola Ltd) | Nigel.Barnes@motorola.com | TSG |
| 42 | 11.2 | TR on different possible architectures |  | 195d? | 2005-03-21 A | 2005-12-16 | 35% | 126.75d? | 2005-03-21 | 2005-12-16 | 195d? | 272d | finish no earlier than 2005-12-16 | S2 | 1560h | 546h | SDoUE | 22.805 | Rel-7 | Maurice |  |  |  |
| 43 | 12 | **FS on IMS with real time services deployment** |  | 384d? | 2004-06-28 A | 2005-12-15 | 75% | 95.33d? | 2004-06-28 | 2005-12-15 | 384d? | 273d |  | S1 | 10680h | 6423.44h | IRTSD |  | Rel-7 | Maurice |  |  | TSG |
| 44 | 12.1 | Feasibility Study on Combining CS calls and IMS sessions |  | 384d? | 2004-06-28 A | 2005-12-15 A | 100% |  | 2004-06-28 | 2005-12-15 | 384d? |  | start no earlier than 2004-06-28 | S1 | 3072h | 3072h | IRTSD-CS_IMS | 22.979, 23.899 | Rel-7 | Michael |  |  | TSG |
| 45 | 12.2 | TR on Stage 2 (IMS services using CS bearers) |  | 316d? | 2004-06-28 A | 2005-09-12 | 65% | 110.6d? | 2004-06-28 | 2005-09-12 | 316d? | 341d | finish no earlier than 2005-09-12 | S2 | 2528h | 1643.2h | IRTSD-IMSCS | 23.899 | Rel-7 | Maurice | Mark Watson (Nortel Networks) |  | TSG |
| 46 | 12.3 | Deleted - TS on Stage 2 (IMS services using CS bearers) |  | 251d? | 2004-06-28 A | 2005-06-13 | 50% | 125.5d? | 2004-06-28 | 2005-06-13 | 251d? | 406d | finish no earlier than 2005-06-13 | S2 | 2008h | 1004h | IRTSD-IMSCS |  | Rel-7 | Maurice | Mark Watson (Nortel Networks) |  | TSG |
| 47 | 13 | **Combinational Services** |  | 205d? | 2005-01-17 A | 2005-10-28 | 42% | 118.01d? | 2005-01-17 | 2005-10-28 | 205d? | 307d |  | S1 | 5696h | 2417.15h | CSICS |  | Rel-7 | Michael | Robert Frank, TeliaSonera | Robert.Frank@teliasonera.com | TSG |
| 48 | 13.1 | Stage 1 for CSICS |  | 104d? | 2005-01-17 A | 2005-06-09 | 85% | 15.6d? | 2005-01-17 | 2005-06-09 | 104d? | 408d | start no earlier than 2005-01-17 | S1 | 832h | 707.2h | CSICS | 22.279 | Rel-7 |  |  |  | TSG |
| 49 | 13.2 | Stage 2 for CSICS |  | 130d? | 2005-01-17 A | 2005-07-15 | 90% | 13d? | 2005-01-17 | 2005-07-15 | 130d? | 382d | start no earlier than 2005-01-17 | S2 | 1040h | 936h | CSICS | 23.279 | Rel-7 |  |  |  |  |
| 50 | 13.3 | Stage 3 for CSICS CN aspects |  | 130d? | 2005-05-02 A | 2005-10-28 | 2% | 127.4d? | 2005-05-02 | 2005-10-28 | 130d? | 307d | start no earlier than 2005-05-01 | C1 | 1040h | 20.8h | CSICS | 24.229, 24.008 | Rel-7 | Andrijana | Peter Dawes (Vodafone) |  | TSG |
| 51 | 13.4 | Stage 3 for codec aspects |  | 143d? | 2005-03-15 A | 2005-09-29 | 5% | 135.85d? | 2005-03-15 | 2005-09-29 | 143d? | 328d | finish no earlier than 2005-09-29 | S4 | 1144h | 57.2h | CSICS-Codec | TS 26.141, 26.235, 26.236 | Rel-7 | Paolo | Per Fröjdh, Ericsson | Per.Frojdh@ericsson.com | TSG |
| 52 | 14 | **All-IP Network (AIPN)** |  | 449d? | 2004-06-28 A | 2006-03-15 | 47% | 237.21d? | 2004-06-28 | 2006-03-15 | 448d? | 208d |  | S1 | 8680h | 4094.34h | AIPN | 22.978 | Rel-7 | Michael | Chris Sachno (NTT DoCoMo) | c.masyu@nttdocomo.co.jp | TSG |
| 53 | 14.1 | All-IP Network Feasibility Study |  | 188d? | 2004-06-28 A | 2005-03-16 A | 100% |  | 2004-06-28 | 2005-03-16 | 188d? |  | start no earlier than 2004-06-28 | S1 | 1504h | 1504h | AIPFS | 22.978 | Rel-7 | Michael | Chris Sachno (NTT DoCoMo) | c.masyu@nttdocomo.co.jp | TSG |
| 54 | 14.2 | Stage1 |  | 448d? | 2004-06-28 A | 2006-03-15 | 25% | 336d? | 2004-06-28 | 2006-03-15 | 448d? | 208d | finish no earlier than 2006-03-15 | S1 | 3584h | 896h | AIPN | 22.258 | Rel-7 | Michael | Chris Sachno (NTT DoCoMo) | c.masyu@nttdocomo.co.jp | TSG |
| 55 | 15 | Enhancement of E2E QoS |  | 336.4d? | 2004-06-28 A | 2005-12-01 | 60% | 134.56d? | 2004-06-28 | 2005-12-01 | 336.4d? | 283d | finish no earlier than 2005-12-01 | S2 | 2691.2h | 1614.72h | QoS7 | 23.802 | Rel-7 | Maurice |  |  | TSG |

Notes:
- 30: Approved SA#27. Appropriate place forEmergency work to be found
- 32: DAB - Should be SA1
- 34: Approved at RP#25 as RP-040387
- 36: Linked SP-040682
- 46: covered by 32084
- 51: Started
- 55: DAB - pushed back to June

| ID | WBS | Task | Type | Duration | Start | Finish | Complete | Remaining | Baseline start | Baseline finish | Baseline duration | Total slack | Constraint | Resources | Work | Actual work | Text1 | Text6 | Text7 | Text8 | Text4 | Text5 |
| --- | --- | --- | --- | --- | --- | --- | --- | --- | --- | --- | --- | --- | --- | --- | --- | --- | --- | --- | --- | --- | --- | --- |
| 56 | 16 | **System enhancements for fixed broadband access to IMS** |  | 353d? | 2004-08-03 A | 2005-12-08 | 46% | 190.24d? | 2004-08-03 | 2005-12-08 | 353d? | 278d |  | S2 | 6873.6h | 3169.22h | FBI | Rel-7 | TSG | Maurice |  |  |
| 57 | 16.1 | Stage 2 |  | 235d? | 2004-10-14 A | 2005-09-07 | 45% | 129.25d? | 2004-10-14 | 2005-09-07 | 235d? | 344d | finish no earlier than 2005-09-07 | S2 | 1880h | 846h | FBI | Rel-7 | TSG | Maurice |  |  |
| 58 | 16.2 | Protocol impact from providing IMS services via fixed broadband |  | 347d? | 2004-08-03 A | 2005-11-30 | 63% | 130d? | 2004-08-03 | 2005-11-30 | 347d? | 284d | finish no earlier than 2005-03-03 | C1 | 2776h | 1736h | FBI | Rel-7 | TSG | Andrijana | Siemens |  |
| 59 | 16.3 | Security Enhancements for Fixed Broadband Access to IMS |  | 118d? | 2005-06-28 | 2005-12-08 |  |  | 2005-06-28 | 2005-12-08 | 118d? | 278d | start no earlier than 2005-06-28 | S3 | 944h |  | ISE | Rel-7 |  | Mike | Bengt Sahlin, Ericsson | Bengt.Sahlin@ericsson.com |
| 60 | 17 | Access Security Enhancements |  | 195d? | 2005-01-03 A | 2005-09-30 | 30% | 136.5d? |  |  |  | 327d | finish no earlier than 2005-09-30 | S3 | 1560h | 468h | ACCSEC2 | Rel-7 | TSG | Michael | Bengt Sahlin, Ericsson | Bengt.Sahlin@ericsson.com |
| 61 | 16.7 | **Deleted - IMS Local services** |  | 1158d? | 2001-01-01 A | 2005-06-08 | 68% | 367.35d? | 2001-01-01 | 2005-06-08 | 1158d? | 409d |  | S2 | 13072h | 5192.02h | IMSLocal | Rel-7 |  |  |  |  |
| 62 | 16.7.1 | Deleted - Stage 2 |  | 325d | 2001-01-01 A | 2002-03-29 A | 100% |  | 2001-01-01 | 2002-03-29 | 325d |  | start no earlier than 2001-01-01 | S2 | 2600h | 2600h | IMSLocal | Rel-7 |  |  |  |  |
| 63 | 18.2 | Delete - Stage 3 for IMS Local services |  | 151d? | 2004-11-10 | 2005-06-08 |  |  | 2004-11-10 | 2005-06-08 | 151d? | 409d | finish no earlier than 2005-06-08 | C1 | 1208h |  | IMSLocal | Rel-7 |  |  | Keith Drage, Lucent | drage@lucent.com |
| 64 | 19 | Mp (MRFC - MRFP) interface |  | 644d | 2002-12-13 | 2005-06-01 |  |  | 2002-12-13 | 2005-06-01 | 644d | 414d | finish no earlier than 2005-06-01 | C4 | 5152h |  | IMSLocal | Rel-7 |  |  |  |  |
| 65 | 20 | IMS Stage 3 IETF Protocol alignment |  | 261d? | 2004-12-10 A | 2005-12-09 | 10% | 234.9d? | 2004-12-10 | 2005-12-09 | 261d? | 277d | finish no earlier than 2005-12-09 | C1 | 2088h | 208.8h | IMSProtoc | Rel-7 |  |  |  |  |
| 66 | 21 | **Rel-7 Improvements of the Radio Interface** |  | 391d? | 2004-09-15 A | 2006-03-15 | 39% | 240.03d? | 2004-09-15 | 2006-03-15 | 390d? | 209d |  | RP | 13040h | 5034.98h | RInImp | Rel-7 |  | Cesar |  |  |
| 67 | 21.1 | UMTS 2.6 GHz |  | 195d? | 2004-09-15 A | 2005-06-14 A | 100% |  | 2004-09-15 | 2005-06-14 | 195d? |  | finish no earlier than 2005-06-14 | R4 | 1560h | 1560h | RInImp-UMTS2600 | Rel-7 | TSG | Cesar | Jussi Numminen, Nokia | jussi.numminen@nokia.com |
| 68 | 21.2 | UMTS 2.6 GHz TDD |  | 261d? | 2004-12-15 A | 2005-12-15 | 35% | 169.65d? | 2004-12-15 | 2005-12-15 | 261d? | 274d | finish no earlier than 2005-12-15 | R4 | 2088h | 730.8h | RInImp-UMTS2600TDD | Rel-7 | TSG | Cesar | Shin Horng Wong (IPWireless) | shwong@IPWIRELESS.COM |
| 69 | 21.3 | UMTS 900 MHz |  | 261d? | 2004-12-15 A | 2005-12-15 | 30% | 182.7d? | 2004-12-15 | 2005-12-15 | 261d? | 274d | finish no earlier than 2005-12-15 | R4 | 2088h | 626.4h | RInImp-UMTS900 | Rel-7 | TSG | Cesar | Yannick Li (Nortel) | yli@nortelnetworks.com |
| 70 | 21.4 | NEW!! UMTS 1700 MHz |  | 197d? | 2005-03-15 | 2005-12-15 |  |  | 2005-03-15 | 2005-12-15 | 197d? | 274d | finish no earlier than 2005-12-15 | R4 | 1576h |  | RInImp-UMTS1700 | Rel-7 | TSG | Cesar | Takehiro Nakamura | NTT DoCoMo |
| 71 | 21.5 | UE Antenna Performance Evaluation Method and Requirements |  | 325d? | 2004-12-15 A | 2006-03-15 | 35% | 211.25d? | 2004-12-15 | 2006-03-15 | 325d? | 209d | finish no earlier than 2006-03-15 | R4 | 2600h | 910h | RInImp-UEAnt | Rel-7 | TSG | Cesar | Christian Bergljung (TeliaSonera) | Christian.Bergljung@TeliaSonera.com |
| 72 | 21.6 | NEW!! Improved Performance Requirements for HSDPA UE based on Rx Diversity (type 1) & LMMSE equalizer (type 2) | milestone | 0d? | 2005-03-15 | 2005-03-15 |  |  | 2005-03-15 | 2005-03-15 | 0d? | 471d | finish no earlier than 2005-03-15 | R4 |  |  | RInImp-HSPerf-Type3 | Rel-7 | TSG | Cesar | Marc Grant | marc.grant@cingular.com |
| 73 | 22 | **7.68Mcps TDD option** |  | 457d? | 2004-09-15 A | 2006-06-15 | 20% | 364.77d? | 2004-09-15 | 2006-06-15 | 456d? | 143d |  | RP | 17736h | 3579.45h | VHCRTDD | Rel-7 | TSG | Cesar | Martin Beale, IPWireless | mbeale@ipwireless.com |
| 74 | 22.1 | VHCRTDD: Stage 2 |  | 326d? | 2004-09-15 A | 2005-12-15 | 15% | 277.1d? | 2004-09-15 | 2005-12-15 | 326d? | 274d | finish no earlier than 2005-12-15 | R1 | 2608h | 391.2h | VHCRTDD-Stage2 | Rel-7 | TSG | Cesar | Martin Beale, IPWireless | mbeale@ipwireless.com |
| 75 | 22.2 | VHCRTDD: Physical Layer |  | 326d? | 2004-09-15 A | 2005-12-15 | 15% | 277.1d? | 2004-09-15 | 2005-12-15 | 326d? | 274d | finish no earlier than 2005-12-15 | R1 | 2608h | 391.2h | VHCRTDD-Phys | Rel-7 | TSG | Cesar | Martin Beale, IPWireless | mbeale@ipwireless.com |
| 76 | 22.3 | VHCRTDD: Layer 2 and layer 3 protocol aspects |  | 326d? | 2004-09-15 A | 2005-12-15 | 15% | 277.1d? | 2004-09-15 | 2005-12-15 | 326d? | 274d | finish no earlier than 2005-12-15 | R2 | 2608h | 391.2h | VHCRTDD-L23 | Rel-7 | TSG | Cesar | Derek Richards, IPWireless | drichards@ipwireless.com |
| 77 | 22.4 | VHCRTDD: UTRAN Iub/Iur Protocol Aspects |  | 326d? | 2004-09-15 A | 2005-12-15 | 15% | 277.1d? | 2004-09-15 | 2005-12-15 | 326d? | 274d | finish no earlier than 2005-12-15 | R3 | 2608h | 391.2h | VHCRTDD-IurIub | Rel-7 | TSG | Cesar | Peter Legg, IPWireless | plegg@ipwireless.com |
| 78 | 22.5 | VHCRTDD: RF Radio Transmission/ Reception, System Performance Requirements and Conformance Testing |  | 456d? | 2004-09-15 A | 2006-06-15 | 35% | 296.4d? | 2004-09-15 | 2006-06-15 | 456d? | 143d | finish no earlier than 2006-06-15 | R4 | 3648h | 1276.8h | VHCRTDD-RF | Rel-7 | TSG | Cesar | Shin Horng Wong | shwong@ipwireless.com |
| 79 | 23 | **Rel-7 RAN improvements** |  | 326d? | 2004-12-15 A | 2006-03-15 | 19% | 263.94d? | 2004-12-15 | 2006-03-15 | 325d? | 209d |  | RP | 8344h | 1588.5h | RANimp | Rel-7 | TSG | Cesar |  |  |
| 80 | 23.1 | Optimisation of channelisation code utilisation for 1.28 Mcps TDD |  | 195d? | 2004-12-15 A | 2005-09-14 | 70% | 58.5d? | 2004-12-15 | 2005-09-14 | 195d? | 340d | finish no earlier than 2005-09-14 | R1 | 1560h | 1092h | RANimp-RABSE-CodOptLCRTDD | Rel-7 | TSG | Cesar | Ka Leong Lo | kaleong.lo@utstar.com |
| 81 | 23.2 | Delay optimisation for procedures applicable to CS and PS Connections |  | 261d? | 2005-03-16 | 2006-03-15 |  |  | 2005-03-15 | 2006-03-15 | 261d? | 209d | finish no earlier than 2006-03-15 | R2 | 2088h |  | RANimp-DelayOpt | Rel-7 | TSG | Cesar | Juho Pirskanen | juho.pirskanen@nokia.com |
| 82 | 23.3 | UE Performance Requirements for MBMS (TDD) |  | 261d? | 2005-03-16 | 2006-03-15 |  |  | 2005-03-15 | 2006-03-15 | 261d? | 209d | finish no earlier than 2006-03-15 | R4 | 2088h |  | MBMS-RAN-RF-TDD | Rel-7 | TSG | Cesar | Shin Horng Wong | shwong@ipwireless.com |
| 83 | 24 | FS on Performance Evaluation of the UE behaviour in high speed trains with speeds up to 350 kmph |  | 261d? | 2005-03-15 A | 2006-03-13 | 5% | 247.95d? | 2005-03-15 | 2006-03-14 | 261d? | 210d | start no earlier than 2005-03-15 | R4 | 2088h | 104.4h | RANFS-HSTrains | Rel-7 | TSG | Cesar | Mike Vogel | Mike.vogel@vodafone.com |

Notes:
- 58: WI sent to NP#25 for approval / Text3: new TR, 24.229, 29.229, 29.163, 29.209
- 59: Duplicated entry ("ACCSEC2", "Access Security Enhancements", SP-040865) deleted by A.Sultan / Text3: 33.102, 43.020
- 60: WID approved SA#26. Record created after SA#27. It is about improved GERAN security / Text3: 33.102, 43.020
- 61: Text3: 23.228
- 62: DAB - Not yet required in SA2 as it exists in previous releases
- 64: 27/11/2002 KK: WID approved at CN#18 (NP-020601)........
- 67: Approved at RP#25 as RP-040377 / Text3: TS25.101, TS25.104, TS25.133, TS25.141, TS25.331, TS25.942, TS25.306, TS25.307, TS34.121
- 68: Text3: 25.102, 25.105, 25.113, 25.123, 25.142, 25.331, 25.942, 25.306, 25.307, 34.122, 34.124
- 69: Text3: 25.101, 25.104, 25.113, 25.133, 25.141, 25.331, 25.942, 25.306, 25.307, 34.121
- 70: Text3: 25.101, 25.104, 25.113, 25.133, 25.141, 25.306, 25.307, 25.331, 34.121
- 71: Text3: TS25.101
- 72: Text3: 25.101
- 73: Approved at RP#25 as RP-040365
- 74: Approved at RP#25 as RP-040365 / Text3: New specification
- 75: Approved at RP#25 as RP-040365 / Text3: TS25.221, TS25.222, TS25.223, TS25.224,TS25.225
- 76: Approved at RP#25 as RP-040365 / Text3: TS25.301, TS25.302, TS25.305, TS25.306, TS25.321, TS25.331
- 77: Approved at RP#25 as RP-040365 / Text3: TS25.401, TS25.420, TS25.423, TS25.425, TS25.427, TS25.430, TS25.433, TS25.435
- 78: Approved at RP#25 as RP-040365 / Text3: TS25.102, TS25.105, TS25.123, TS25.133, TS25.142
- 79: Generic feature
- 81: Text3: TS25.321, TS25.322, TS25.331
- 82: Text3: TS25.102, TS25.123

| ID | WBS | Task | Duration | Start | Finish | Complete | Remaining | Baseline start | Baseline finish | Baseline duration | Total slack | Constraint | Resources | Work | Actual work | Text1 | Text4 | Text5 | Text6 | Text7 | Text8 |
| --- | --- | --- | --- | --- | --- | --- | --- | --- | --- | --- | --- | --- | --- | --- | --- | --- | --- | --- | --- | --- | --- |
| 84 | 25 | **3.84 Mcps TDD Enhanced Uplink** | 328d? | 2005-03-15 A | 2006-06-15 | 7% | 303.41d? | 2005-03-15 | 2006-06-15 | 327d? | 143d |  | RP | 13080h | 980.75h | EDCHTDD | Nicholas Anderson | nanderson@ipwireless.com | Rel-7 | TSG | Cesar |
| 85 | 25.1 | EDCHTDD: Stage 2 | 197d? | 2005-03-15 A | 2005-12-14 | 10% | 177.3d? | 2005-03-15 | 2005-12-14 | 197d? | 274d | start no earlier than 2005-03-15 | R2 | 1576h | 157.6h | EDCHTDD-Stage2 | Nicholas Anderson | nanderson@ipwireless.com | Rel-7 | TSG | Cesar |
| 86 | 25.2 | EDCHTDD: Physical Layer | 261d? | 2005-03-15 A | 2006-03-13 | 10% | 234.9d? | 2005-03-15 | 2006-03-14 | 261d? | 210d | start no earlier than 2005-03-15 | R1 | 2088h | 208.8h | EDCHTDD-Phys | Nicholas Anderson | nanderson@ipwireless.com | Rel-7 | TSG | Cesar |
| 87 | 25.3 | EDCHTDD: Layer 2 and 3 Protocol Aspects | 261d? | 2005-03-15 A | 2006-03-13 | 15% | 221.85d? | 2005-03-15 | 2006-03-14 | 261d? | 210d | start no earlier than 2005-03-15 | R2 | 2088h | 313.2h | EDCHTDD-L23 | Derek Richards | drichards@ipwireless.com | Rel-7 | TSG | Cesar |
| 88 | 25.4 | EDCHTDD: UTRAN Iub/Iur Protocol Aspects | 261d? | 2005-03-15 A | 2006-03-13 | 5% | 247.95d? | 2005-03-15 | 2006-03-14 | 261d? | 210d | start no earlier than 2005-03-15 | R3 | 2088h | 104.4h | EDCHTDD-IurIub | Jim Miller | jim.miller@interdigital.com | Rel-7 | TSG | Cesar |
| 89 | 25.5 | EDCHTDD: RF Radio Transmission/ Reception, System Performance Requirements and Conformance Testing | 327d? | 2005-03-16 | 2006-06-15 |  |  | 2005-03-15 | 2006-06-15 | 327d? | 143d | finish no earlier than 2006-06-15 | R4 | 2616h |  | EDCHTDD-RF | Shin Horng Wong | shwong@ipwireless.com | Rel-7 | TSG | Cesar |
| 90 | 26 | **Support of SMS and MMS over generic 3GPP IP access** | 433d? | 2004-10-14 A | 2006-06-09 | 40% | 261.58d? | 2004-10-14 | 2005-06-13 | 173d? | 146d |  | S2 | 6960h | 2560.4h | SMSIP |  |  | Rel-7 | TSG |  |
| 91 | 26.1 | FS on SMSIP | 173d? | 2004-10-14 A | 2005-06-13 A | 100% |  | 2004-10-14 | 2005-06-13 | 173d? |  | start no earlier than 2004-10-14 | S2 | 1384h | 1384h | SMSIP |  |  | Rel-7 |  |  |
| 92 | 26.2 | Stage 2 for SMSIP | 264d? | 2005-06-08 | 2006-06-09 |  |  | 2005-06-07 | 2005-06-07 | 0d? | 146d | finish no earlier than 2006-06-09 | S2 | 2112h |  | SMSIP |  |  | Rel-7 |  |  |
| 93 | 27 | Evolution of Policy Control and Charging | 315d? | 2004-10-14 A | 2005-12-28 | 50% | 157.5d? | 2004-10-14 | 2005-12-28 | 315d? | 263d | finish no earlier than 2005-12-28 | S2 | 2520h | 1260h | PCC |  |  | Rel-7 | TSG | Maurice |
| 94 | 28 | TR for PCC | 315d? | 2004-10-14 A | 2005-12-28 | 60% | 126d? |  |  |  | 263d | finish no earlier than 2005-12-28 | S2 | 2520h | 1512h | PCC |  |  | Rel-7 |  |  |
| 95 | 29 | Stage 2 for PCC | 250d? | 2005-07-04 | 2006-06-15 |  |  |  |  |  | 142d | start no earlier than 2005-07-04 | S2 | 2000h |  | PCC |  |  | Rel-7 |  |  |
| 96 | 30 | **Advanced Global Navigation Satellite System (A-GNSS) concept** | 329d? | 2004-06-28 A | 2005-09-29 | 22% | 255.77d? | 2004-06-28 | 2005-09-29 | 329d? | 328d |  | S1 | 7241.6h | 1176.4h | LCS3-AGNSS | Michel MONNERAT | Michel.monnerat@space.alcatel.fr | Rel-7 | TSG | Michael |
| 97 | 30.1 | Support for GNSS in GERAN | 291.2d? | 2004-06-28 | 2005-09-02 |  |  | 2004-06-28 | 2005-09-02 | 291.2d? | 347d | finish no earlier than 2005-09-02 | GP | 2329.6h |  | AGNSS-GP | Richard Couty, ALCATEL SA | richard.couty@space.alcatel.fr | Rel-7 | TSG | Paolo |
| 98 | 30.2 | Towards A-GNSS Concept | 285d? | 2004-08-27 A | 2005-09-29 | 45% | 156.75d? | 2004-08-27 | 2005-09-29 | 285d? | 328d | finish no earlier than 2005-09-29 | S1 | 2280h | 1026h | GNSS | Richard Couty, ALCATEL SA | richard.couty@space.alcatel.fr | Rel-7 | TSG | Paolo |
| 99 | 31 | Video Codec Performance Requirements | 314d? | 2005-01-03 A | 2006-03-16 | 15% | 266.9d? | 2005-01-03 | 2006-03-16 | 314d? | 207d | finish no earlier than 2006-03-16 | S4 | 2512h | 376.8h | VICPer | Juergen Pandel (Siemens AG) | juergen.pandel@siemens.com | Rel-7 | TSG | Paolo |
| 100 | 32 | DIAMETER on the GGSN Gi interface | 266d? | 2004-09-10 | 2005-09-16 |  |  | 2004-09-10 | 2005-09-16 | 266d? | 337d | finish no earlier than 2005-09-16 | C3 | 2128h |  | DIAMGi | Stefan Koppenborg (T-Mobile) | stefan.koppenborg@t-mobile.de | Rel-7 | TSG | Seung Don |
| 101 | 33 | **CAMEL Trunk Triggers** | 251d? | 2004-12-17 A | 2005-12-05 | 53% | 119.22d? | 2004-12-17 | 2005-12-05 | 251d? | 281.5d |  | S1 | 6024h | 3162.6h | TTCAMEL | Amar Deol, Nortel Networks | deola@nortelnetworks.com | Rel-7 | TSG | Michael |
| 102 | 33.1 | Stage 1 for CAMEL Trunk Triggers | 251d? | 2004-12-17 A | 2005-12-05 | 95% | 12.55d? | 2004-12-17 | 2005-12-05 | 251d? | 281.5d |  | S1 | 2008h | 1907.6h | TTCAMEL | Amar Deol, Nortel Networks | deola@nortelnetworks.com | Rel-7 | TSG | Michael |
| 103 | 33.2 | CAMEL Trunk Originated Trigger Detection Points | 251d? | 2004-12-17 A | 2005-12-05 | 10% | 225.9d? | 2004-12-17 | 2005-12-05 | 251d? | 281.5d | start no earlier than 2004-12-17 | C4 | 2008h | 200.8h | CamelR7 | David Hutton, Nortel Networks | dhutton@nortel.com | Rel-7 | TSG | Kimmo |
| 104 | 34 | MS Antenna Performance Evaluation Method and Requirements | 206d? | 2005-01-28 | 2005-11-11 |  |  | 2005-01-28 | 2005-11-11 | 206d? | 297d | finish no earlier than 2005-11-11 | G1 | 1648h |  | APEMR | Ulf.Tegth (TeliaSonera) | Ulf.Tegth@teliasonera.com | Rel-7 | TSG | Paolo |
| 105 | 35 | Lower 700 MHz Inclusion in the GERAN Specifications | 106d? | 2005-01-28 A | 2005-06-24 | 70% | 31.8d? | 2005-01-28 | 2005-06-24 | 106d? | 397d | finish no earlier than 2005-06-24 | GP | 848h | 593.6h | GSM710 | Dave Cotton (UTC) | dcotton@mtview.union-tel.com | Rel-7 | TSG | Paolo |
| 106 | 36 | **3GPP System Architecture Evolution** | 402d? | 2004-12-03 A | 2006-06-16 | 27% | 293.19d? | 2004-12-03 | 2006-06-16 | 401d? | 141d |  | S2 | 8112h | 2195.67h | SAE |  |  | Rel-7 | TSG |  |
| 107 | 36.1 | Stage 2 description of Interim conclusion | 211d? | 2004-12-03 A | 2005-09-23 | 50% | 105.5d? | 2004-12-03 | 2005-09-23 | 211d? | 332d | finish no earlier than 2005-09-23 | S2 | 1688h | 844h | SAE |  |  | Rel-7 |  |  |
| 108 | 36.2 | Stage 2 Feasibility study on 3GPP architectural development | 401d? | 2004-12-03 A | 2006-06-16 | 15% | 340.85d? | 2004-12-03 | 2006-06-16 | 401d? | 141d | finish no earlier than 2006-06-16 | S2 | 3208h | 481.2h | SAE |  |  | Rel-7 |  |  |

Notes:
- 86: Text3: TS25.201, TS25.221,TS25.222, TS25.223, TS25.224, TS25.225
- 87: Text3: TS25.301, TS25.302, TS25.306, TS25.321, TS25.331
- 88: Text3: TS25.401, TS25.420, TS25.423, TS25.427, TS25.430, TS25.433, TS25.435
- 89: Text3: TS25.102, TS25.105, TS25.123, TS25.142
- 90: DAB - pushed back to June
- 97: Not started
- 99: Text3: 26.234, 26.235, 26.346, 26.140
- 100: Not started
- 103: Not started
- 104: Started / Text3: 25.9xx, 45.005
- 105: Started / Text3: 24.008, 43.022, 44.018, 44.118, 45, 001, 45.005, 51.010, 51.021
- 107: Text3: 23.8xx
- 108: Text3: 23.8xx

| ID | WBS | Task | Type | Duration | Start | Finish | Complete | Remaining | Baseline start | Baseline finish | Baseline duration | Total slack | Constraint | Resources | Work | Actual work | Text1 | Text3 | Text4 | Text6 | Text7 | Text8 | Text5 | Text10 |
| --- | --- | --- | --- | --- | --- | --- | --- | --- | --- | --- | --- | --- | --- | --- | --- | --- | --- | --- | --- | --- | --- | --- | --- | --- |
| 109 | 37 | **Enhancements of VGCS for public authority officials** |  | 0d? | 2004-08-27 A | 2004-08-27 |  | 0d? | 2004-08-27 | 2004-08-27 | 0d? | 613d |  | C1 |  |  | EGCS | 43.068, 44.068, 24.008, 29.002 | Siemens | Rel-7 | TSG | Andrijana |  |  |
| 110 | 37.1 | Stage 1 | milestone | 0d? | 2004-08-27 A | 2004-08-27 A | 100% |  | 2004-08-27 | 2004-08-27 | 0d? |  | finish no earlier than 2004-08-27 | S1 |  |  | EGCS | 42.068, 43.068 | Joerg Swetina (Siemens AG) | Rel-7 | TSG | Michael | joerg.swetina@SIEMENS.COM |  |
| 111 | 37.2 | GERAN2 aspects | milestone | 0d? | 2004-08-27 | 2004-08-27 |  |  | 2004-08-27 | 2004-08-27 | 0d? | 613d | finish no earlier than 2004-08-27 | G2 |  |  | EVGCS |  | Ken Isaacs (Siemens) | Rel-7 | TSG | Paolo | kenneth.isaacs@roke.co.uk |  |
| 112 | 38 | **Improvements of VGCS for parallel use of services** |  | 337d? | 2004-06-28 A | 2005-10-11 | 9% | 306.65d? | 2004-06-28 | 2005-10-11 | 337d? | 320d |  | C1 | 8312.02h | 748.68h | IVGCS |  |  | Rel-7 |  |  |  |  |
| 113 | 38.1 | Deleted - Enhancements of VGCS |  | 337d? | 2004-06-28 A | 2005-10-11 | 19% | 273.77d? | 2004-06-28 | 2005-10-11 | 337d? | 320d |  | S1 | 2696.02h | 505.85h | EGCS | 42.068, 43.068 | Joerg Swetina (Siemens AG) | Rel-7 | TSG | Michael | joerg.swetina@SIEMENS.COM |  |
| 114 | 38.2 | Deleted- Stage 1 |  | 161d? | 2005-03-01 | 2005-10-11 |  |  | 2005-03-01 | 2005-10-11 | 161d? | 320d | start no earlier than 2005-03-01 | S1 | 1288h |  | IVGCS | 42.068 | Kurt Bischinger (T-Mobile) | Rel-7 | TSG | Michael | kurt.bischinger@t-mobile.at |  |
| 115 | 38.3 | Service Requirements for VGCS improvements |  | 62d? | 2005-03-15 | 2005-06-08 |  |  | 2005-03-15 | 2005-06-08 | 62d? | 409d | finish no earlier than 2005-06-08 | S1 | 496h |  | IVGCS | 42.068 | Kurt Bischinger (T-Mobile) | Rel-7 | TSG | Michael | kurt.bischinger@t-mobile.at |  |
| 116 | 38.4 | Stage 2 modifications for VGCS improvements |  | 142d? | 2005-03-15 | 2005-09-28 |  |  | 2005-03-15 | 2005-09-28 | 142d? | 329d | finish no earlier than 2005-09-28 | C1 | 1136h |  | IVGCS | 42.068 | Kurt Bischinger (T-Mobile) | Rel-7 | TSG |  | kurt.bischinger@t-mobile.at |  |
| 117 | 39 | **Rel-7 OSA Service broker** |  | 142d? | 2005-03-15 A | 2005-09-28 | 20% | 113.95d? | 2005-03-15 | 2005-09-28 | 142d? | 329d |  | S1 | 2768h | 546.82h | OSA7-SB |  | Eamonn Murray (AePONA) | Rel-7 | TSG | Michael | eamonn.murray@aepona.com |  |
| 118 | 39.1 | Service Requirements for OSA Service Broker |  | 62d? | 2005-03-15 A | 2005-06-08 | 65% | 21.7d? | 2005-03-15 | 2005-06-08 | 62d? | 409d | finish no earlier than 2005-06-08 | S1 | 496h | 322.4h | OSA7-SB | 22.127 | Eamonn Murray (AePONA) | Rel-7 | TSG | Michael | eamonn.murray@aepona.com |  |
| 119 | 39.2 | Stage 2 modifications for OSA Service Broker |  | 142d? | 2005-03-15 | 2005-09-28 |  |  | 2005-03-15 | 2005-09-28 | 142d? | 329d | finish no earlier than 2005-09-28 | CT5 | 1136h |  | OSA7-SB | 23.127 | Eamonn Murray (AePONA) | Rel-7 | TSG | Adrian | eamonn.murray@aepona.com |  |
| 120 | 40 | Dynamic and interactive multimedia scenes |  | 194d? | 2005-03-15 A | 2005-12-09 | 5% | 184.3d? | 2005-03-15 | 2005-12-09 | 194d? | 277d | finish no earlier than 2005-12-09 | S4 | 1552h | 77.6h | DIMS | 26.234, 23.346, 26.140, 26.244 | Gaëlle MARTIN-COCHER (Streamezzo) | Rel-7 | TSG | Paolo | gaelle.martin-cocher@streamezzo.com |  |
| 121 | 41 | Liberty Alliance and 3GPP Security Interworking |  | 147d? | 2005-03-10 A | 2005-09-30 | 10% | 132.3d? | 2005-03-10 | 2005-09-30 | 147d? | 327d | finish no earlier than 2005-09-30 | S3 | 1176h | 117.6h | LibSec |  | Silke Holtmanns, Nokia | Rel-7 | TSG | Maurice | Silke.Holtmanns@NOKIA.COM |  |
| 122 | 42 | FS of enhanced support of Video Telephony |  | 266d? | 2004-08-27 A | 2005-09-02 | 35% | 172.9d? | 2004-08-27 | 2005-09-02 | 266d? | 347d | finish no earlier than 2005-09-02 | GP | 2128h | 744.8h | VIDGER |  | Stefan Eriksson, Ericsson | Rel-7 | TSG | Paolo | stefan.g.eriksson@ericsson.com |  |
| 123 | 43 | FS on Evolved UTRA and UTRAN |  | 130d? | 2004-12-15 A | 2005-06-15 | 20% | 104d? | 2004-12-15 | 2005-06-15 | 130d? | 405d | finish no earlier than 2005-06-15 | RP | 1040h | 208h | RANFS-Evo |  | Takehiro Nakamura (NTT DoCoMo) | Rel-7 | TSG | Cesar | nakamurata@NTTDOCOMO.CO.JP |  |
| 124 | 44 | **Study on Videotelephony teleservice** |  | 453d? | 2005-03-15 A | 2006-12-06 | 30% | 317.1d? | 2005-03-15 | 2006-12-06 | 452d? | 18d |  | S1 | 7240h | 2172h | VidTel |  | Kurt Bischinger (T-Mobile) | Rel-7 | TSG | Michael | kurt.bischinger@t-mobile.at |  |
| 125 | 44.1 | Study on Videotelephony service requirements |  | 452d? | 2005-03-15 A | 2006-12-06 | 30% | 316.4d? | 2005-03-15 | 2006-12-06 | 452d? | 18d | finish no earlier than 2006-12-06 | S1 | 3616h | 1084.8h | VidTel | 22.101 | Kurt Bischinger (T-Mobile) | Rel-7 | TSG | Michael | kurt.bischinger@t-mobile.at |  |
| 126 | 45 | **Study of Network Selection Principles** |  | 193d? | 2005-03-15 A | 2005-12-08 | 33% | 129.31d? | 2005-03-15 | 2005-12-08 | 193d? | 278d |  | S1 | 3088h | 1623.54h | NetSel |  | Chris Friel (O2) | Rel-7 | TSG | Michael | chris.friel@o2.com |  |
| 127 | 45.1 | Review of Network Selection Principles |  | 193d? | 2005-03-15 A | 2005-12-08 | 33% | 129.31d? | 2005-03-15 | 2005-12-08 | 193d? | 278d | finish no earlier than 2005-12-08 | S1 | 1544h | 509.52h | NetSel | 22.811 | Chris Friel (O2) | Rel-7 | TSG | Michael | chris.friel@o2.com |  |
| 128 | 46 | Behaviour of Multi system UEs |  | 188d? | 2004-06-28 A | 2005-03-16 | 60% | 75.2d? | 2004-06-28 | 2005-03-16 | 188d? | 469d | start no earlier than 2004-06-28 | S1 | 1504h | 902.4h | BMSU | 22.936 | D Williams (QUALCOMM) | Rel-7 | TSG | Michael | dwilliams@qualcomm.com |  |
| 129 | 47 | **WLAN-UMTS Interworking Phase 2** |  | 371d? | 2004-01-05 A | 2005-06-07 | 99% | 0d? | 2004-01-05 | 2005-06-07 | 371d? | 411d |  | S1 | 3888h | 3888h |  |  | Fredric Paint, Telenor | Rel-7 | TSG | Michael | frederic.paint@telenor.com |  |
| 130 | 47.1 | Stage 1 on Session Continuity |  | 115d? | 2004-01-05 A | 2004-06-11 A | 100% |  | 2004-01-05 | 2004-06-11 | 115d? |  | start no earlier than 2004-01-05 | S1 | 920h | 920h | WLAN-SC |  |  | Rel-7 |  |  |  | SP-24 |
| 131 | 47.2 | Stage 2 on Session Continuity: covered by SAE | milestone | 0d? | 2005-06-07 | 2005-06-07 |  |  | 2005-06-07 | 2005-06-07 | 0d? | 411d | finish no earlier than 2005-06-07 | S2 |  |  |  |  |  | Rel-7 |  |  |  |  |
| 132 | 48 | Voice call continuity between CS and IMS (incl. I-WLAN) |  | 321d? | 2004-12-31 A | 2006-03-23 | 30% | 224.7d? | 2005-03-14 | 2005-12-24 | 205d? | 202d | start no earlier than 2004-12-31 | S2 | 2568h | 770.4h | VCC | 22.101, 22.228, 23.228 | Andy Bennett, Lucent; Roger Bunting, Cingular | Rel-7 |  | Maurice | andybennett@lucent.com |  |
| 133 | 49 | DIAMETER on the PDG Wi inteface |  | 266d? | 2004-09-10 | 2005-09-16 |  |  | 2004-09-10 | 2005-09-16 | 266d? | 337d | finish no earlier than 2005-09-16 | C3 | 2128h |  | DIAMWi |  | Stefan Koppenborg (T-Mobile) | Rel-7 | TSG | Seung Don | stefan.koppenborg@t-mobile.de |  |
| 134 | 50 | TR for VCC |  | 196d? | 2004-12-31 A | 2005-09-30 | 50% | 98d? |  |  |  | 327d | finish no earlier than 2005-09-30 | S2 | 1568h | 784h | VCC |  |  | Rel-7 |  |  |  |  |
| 135 | 51 | Stage 2 for VCC |  | 79d? | 2005-09-07 | 2005-12-24 |  |  |  |  |  | 266d | finish no earlier than 2005-12-24 | S2 | 632h |  | VCC |  |  | Rel-7 |  |  |  |  |
| 136 | 52 | FS on Enhancements to support QoS provisioning over 3GPP/WLAN Interworking |  | 392d? | 2005-03-14 A | 2006-09-11 | 20% | 313.6d? | 2005-03-14 | 2006-09-12 | 392d? | 80d | start no earlier than 2005-03-14 | S2 | 3136h | 627.2h | WLAN-SC |  | Osok Song, Samsung | Rel-7 |  | Maurice | osok.song@samsung.com |  |

Notes:
- 109: moved to Rel6
- 113: covered by Rel6's UID 11045
- 114: covered by UID 31070
- 120: Started
- 121: WID approved SA#27.
- 122: FS started
- 123: vice rapporteur Don Zelmar (Cingular)
- 128: This is a feature in its own right.
- 129: Created at TSG#27 by A. Sultan because of WLAN items belonging to Rel-7
- 132: WID approved SA#27. Revised at SA#28.
- 133: Not started
- 136: Approved SA#27. BB Position in Work Plan to be confirmed

| ID | WBS | Task | Duration | Start | Finish | Complete | Remaining | Baseline start | Baseline finish | Baseline duration | Total slack | Constraint | Resources | Work | Actual work | Text1 | Text3 | Text4 | Text5 | Text6 | Text7 | Text8 |
| --- | --- | --- | --- | --- | --- | --- | --- | --- | --- | --- | --- | --- | --- | --- | --- | --- | --- | --- | --- | --- | --- | --- |
| 137 | 53 | **OAM&P Rel-7** | 752d? | 2004-02-16 A | 2006-12-29 |  | 750.01d? | 2004-02-16 | 2006-12-29 | 750d? | 0d |  | S5 | 37128h | 3889.42h | OAM7 | 32-series | Michael TRUSS (Motorola) | Michael.Truss@MOTOROLA.COM | Rel-7 | TSG | Adrian |
| 138 | 53.1 | **Network Infrastructure Management** | 342d? | 2005-09-02 | 2006-12-22 |  |  | 2005-09-02 | 2006-12-22 | 341d? | 6d |  | S5 | 16408h |  | OAM7-NIM |  | Michael TRUSS (Motorola) | Michael.Truss@MOTOROLA.COM | Rel-7 |  |  |
| 139 | 53.1.1 | Enhance NRM to accommodate NGN (IMS as basis of the Next Generation Network) | 341d? | 2005-09-05 | 2006-12-22 |  |  | 2005-09-02 | 2006-12-22 | 341d? | 6d | finish no earlier than 2006-12-22 | S5 | 2728h |  | OAM7-NIM-NGN |  | BT |  | Rel-7 |  |  |
| 140 | 53.1.2 | IRP usage scenarios | 69d? | 2005-09-02 | 2005-12-07 |  |  | 2005-09-02 | 2005-12-07 | 69d? | 279d | finish no earlier than 2005-12-07 | S5 | 552h |  | OAM7-NIM |  | Lucent |  | Rel-7 |  |  |
| 141 | 53.1.3 | Co-operative Element Management interface (CO-OP) | 151d? | 2005-09-05 | 2006-03-31 |  |  | 2005-09-02 | 2006-03-31 | 151d? | 196d | finish no earlier than 2006-03-31 | S5 | 1208h |  | OAM7-NIM-COOP |  | Motorola |  | Rel-7 |  |  |
| 142 | 53.1.4 | Network Management (NM) Itf-N performance criteria | 69d? | 2005-09-02 | 2005-12-07 |  |  | 2005-09-02 | 2005-12-07 | 69d? | 279d | finish no earlier than 2005-12-07 | S5 | 552h |  | OAM7-NIM |  | China Mobile |  | Rel-7 |  |  |
| 143 | 53.1.5 | Delta synchronization between IRP Manager and IRP Agent | 69d? | 2005-09-02 | 2005-12-07 |  |  | 2005-09-02 | 2005-12-07 | 69d? | 279d | finish no earlier than 2005-12-07 | S5 | 552h |  | OAM7-NIM |  | Siemens |  | Rel-7 |  |  |
| 144 | 53.1.6 | Subscription Management (SuM) IRP Solution Sets | 151d? | 2005-09-05 | 2006-03-31 |  |  | 2005-09-02 | 2006-03-31 | 151d? | 196d | finish no earlier than 2006-03-31 | S5 | 1208h |  | OAM7-NIM-SuM |  | T-Mobile |  | Rel-7 |  |  |
| 145 | 53.1.7 | Integration Reference Point (IRP) Security Management | 216d? | 2005-09-05 | 2006-06-30 |  |  | 2005-09-02 | 2006-06-30 | 216d? | 131d | finish no earlier than 2006-06-30 | S5 | 1728h |  | OAM7-NIM |  | Huawei |  | Rel-7 |  |  |
| 146 | 53.1.8 | Integration Reference Point (IRP) Methodology | 69d? | 2005-09-02 | 2005-12-07 |  |  | 2005-09-02 | 2005-12-07 | 69d? | 279d | finish no earlier than 2005-12-07 | S5 | 552h |  | OAM7-NIM |  | Ericsson |  | Rel-7 |  |  |
| 147 | 53.1.9 | Partial suspension of Itf-N during maintenance/testing | 69d? | 2005-09-02 | 2005-12-07 |  |  | 2005-09-02 | 2005-12-07 | 69d? | 279d | finish no earlier than 2005-12-07 | S5 | 552h |  | OAM7-NIM |  | Siemens |  | Rel-7 |  |  |
| 148 | 53.1.10 | Advanced Alarming on Itf-N | 216d? | 2005-09-05 | 2006-06-30 |  |  | 2005-09-02 | 2006-06-30 | 216d? | 131d | finish no earlier than 2006-06-30 | S5 | 1728h |  | OAM7-NIM |  | Siemens |  | Rel-7 |  |  |
| 149 | 53.1.11 | Management of Legacy Equipment | 69d? | 2005-09-02 | 2005-12-07 |  |  | 2005-09-02 | 2005-12-07 | 69d? | 279d | finish no earlier than 2005-12-07 | S5 | 552h |  | OAM7-NIM |  | Siemens |  | Rel-7 |  |  |
| 150 | 53.1.12 | Rules for Vendor Specific Extensions | 151d? | 2005-09-05 | 2006-03-31 |  |  | 2005-09-02 | 2006-03-31 | 151d? | 196d | finish no earlier than 2006-03-31 | S5 | 1208h |  | OAM7-NIM |  | Siemens |  | Rel-7 |  |  |
| 151 | 53.1.13 | CN CS Bearer Transport Network (BTN) relative NRM | 69d? | 2005-09-02 | 2005-12-07 |  |  | 2005-09-02 | 2005-12-07 | 69d? | 279d | finish no earlier than 2005-12-07 | S5 | 552h |  | OAM7-NIM |  | China Mobile |  | Rel-7 |  |  |
| 152 | 53.2 | **Performance Management** | 348d? | 2005-09-02 | 2006-12-29 |  |  | 2005-09-02 | 2006-12-29 | 346d? | 0d |  | S5 | 8416h |  | OAM7-PM |  | Christian TOCHE (Nortel) | toche@NORTEL.COM | Rel-7 |  |  |
| 153 | 53.2.1 | Performance measurements definition for CN CS | 151d? | 2005-09-05 | 2006-03-31 |  |  | 2005-09-02 | 2006-03-31 | 151d? | 196d | finish no earlier than 2006-03-31 | S5 | 1208h |  | OAM7-PM |  | China Mobile |  | Rel-7 |  |  |
| 154 | 53.2.2 | Enhancement UTRAN performance measurements definition | 69d? | 2005-09-02 | 2005-12-07 |  |  | 2005-09-02 | 2005-12-07 | 69d? | 279d | finish no earlier than 2005-12-07 | S5 | 552h |  | OAM7-PM |  | China Mobile |  | Rel-7 |  |  |
| 155 | 53.2.3 | Add TDD specific counters in Performance measurement | 346d? | 2005-09-06 | 2006-12-29 |  |  | 2005-09-02 | 2006-12-29 | 346d? | 0d | finish no earlier than 2006-12-29 | S5 | 2768h |  | OAM7-PM |  | CATT |  | Rel-7 |  |  |
| 156 | 53.2.4 | ATM bearer network Performance measurements | 69d? | 2005-09-02 | 2005-12-07 |  |  | 2005-09-02 | 2005-12-07 | 69d? | 279d | finish no earlier than 2005-12-07 | S5 | 552h |  | OAM7-PM |  | ZTE |  | Rel-7 |  |  |
| 157 | 53.2.5 | IP bearer network Performance measurement definitions | 69d? | 2005-09-02 | 2005-12-07 |  |  | 2005-09-02 | 2005-12-07 | 69d? | 279d | finish no earlier than 2005-12-07 | S5 | 552h |  | OAM7-PM |  | China Mobile |  | Rel-7 |  |  |
| 158 | 44.5 | **Trace Management Rel-7** | 474d? | 2004-02-16 A | 2005-12-08 | 2% | 466.66d? | 2004-02-16 | 2005-12-08 | 474d? | 278d |  | S5 | 6288h | 97.42h | OAM-Trace |  | Christian TOCHE (Nortel) | toche@NORTEL.COM | Rel-7 | TSG |  |
| 159 | 53.3.1 | Trace Management for IMS | 154d? | 2005-05-09 A | 2005-12-08 | 5% | 146.3d? | 2005-05-09 | 2005-12-08 | 154d? | 278d | finish no earlier than 2005-12-08 | S5 | 1232h | 61.6h | OAM7-Trace-IMS | 32.421/2/3 | Nortel, CATT |  | Rel-7 | TSG |  |
| 160 | 53.3.2 | SIP enhancements for trace | 343d? | 2004-02-16 A | 2005-06-17 |  | 343d? | 2004-02-16 | 2005-06-17 | 343d? | 402.14d | finish no earlier than 2005-06-08 | C1 | 2744h |  | Trace-SIP |  |  |  | Rel-7 |  |  |

Notes:
- 137: Created at TSG#27 by A. Sultan due to the split of the OAM BB Trace Rel-6/Rel-7
- 138: SA#28 (06/2005) created
- 139: SA#28 (06/2005) created
- 140: SA#28 (06/2005) created
- 141: SA#28 (06/2005) created
- 142: SA#28 (06/2005) created
- 143: SA#28 (06/2005) created
- 144: SA#28 (06/2005) created
- 145: SA#28 (06/2005) created
- 146: SA#28 (06/2005) created
- 147: SA#28 (06/2005) created
- 148: SA#28 (06/2005) created
- 149: SA#28 (06/2005) created
- 150: SA#28 (06/2005) created
- 151: SA#28 (06/2005) created
- 152: SA#28 (06/2005) created
- 155: SA#28 (06/2005) created
- 156: SA#28 (06/2005) created
- 157: SA#28 (06/2005) created
- 158: TSG#27: SA5 BB WID to add Trace for IMS (SIP) CN1 24.229 has IETF dependency

| ID | WBS | Task | Type | Duration | Start | Finish | Complete | Remaining | Baseline start | Baseline finish | Baseline duration | Total slack | Constraint | Resources | Work | Actual work | Text6 | Text8 | Text7 | Text1 | Text4 | Text5 |
| --- | --- | --- | --- | --- | --- | --- | --- | --- | --- | --- | --- | --- | --- | --- | --- | --- | --- | --- | --- | --- | --- | --- |
| 161 | 54 | **TBC: Generic User Profile Phase 2** |  | 820.4d | 2002-01-01 A | 2005-02-22 |  | 820.4d | 2002-01-01 | 2005-02-22 | 820.4d | 485.6d |  | C4 | 9376h |  | Rel-7 | Gaby |  |  |  |  |
| 162 | 30.4 | Stage 3 - Common objects |  | 586d | 2002-01-01 A | 2005-02-22 |  | 586d | 2002-01-01 | 2005-02-22 | 586d | 485.6d | finish no earlier than 2005-03-03 | C4 | 4688h |  | Rel-7 | Gaby | TSG |  |  |  |
| 163 | 55 | Deleted - IMS Phase 3 | milestone | 0d? | 2005-06-08 A | 2005-06-08 A | 100% |  | 2005-06-08 | 2005-06-08 | 0d? |  | finish no earlier than 2005-06-08 | S2 |  |  | Rel-7 |  |  |  |  |  |
| 164 | 56 | Deleted - Improvements of Radio Interface | milestone | 0d? | 2004-09-15 A | 2004-09-15 A | 100% |  | 2004-09-15 | 2004-09-15 | 0d? |  | start no earlier than 2004-09-15 | RP |  |  | Rel-7 | Cesar | TSG | RInImp |  |  |
| 165 | 57 | Trust Requirements for Open Platforms in 3GPP |  | 115d? | 2005-01-03 A | 2005-06-10 | 10% | 103.5d? | 2005-01-03 | 2005-06-10 | 115d? | 407d | finish no earlier than 2005-06-10 | S3 | 920h | 92h | Rel-7 | Michael | TSG | TrustOP | Selim Aissi, Sundeep Bajikar, Intel Corporation | selim.aissi@intel.com; sundeep.bajikar@intel.com |
| 166 | 58 | Development of UEA2 and UIA2 |  | 268d? | 2004-12-01 A | 2005-12-09 | 50% | 134d? | 2004-12-01 | 2005-12-09 | 268d? | 277d | finish no earlier than 2005-12-09 | S3 | 2144h | 1072h | Rel-7 | Michael | TSG | AlgUEA2 | Per Christoffersson, Teliasonera | per.christoffersson@teliasonera.com |
| 167 | 59 | Lawful Interception in the 3GPP Rel-7 architecture |  | 118d? | 2005-06-28 | 2005-12-08 |  |  | 2005-06-28 | 2005-12-08 | 118d? | 278d | start no earlier than 2005-06-28 | S3 | 944h |  | Rel-7 | Mike |  | LI-7A | Berthold Wilhelm, BMWI | berthold.wilhelm@regtp.de |
| 168 | 60 | **Support of Conversational Services in A/Gb mode via the PS domain** |  | 277d? | 2005-04-08 A | 2006-04-28 | 10% | 249.3d? | 2005-04-08 | 2006-04-28 | 276d? | 176d |  | GP | 8619.2h | 861.92h | Rel-7 | Paolo |  | SCSAGB | Gunnar Hedby, Ericsson | gunnar.hedby@ericsson.com |
| 169 | 60.1 | Definition of radio resource management functionality |  | 276d? | 2005-04-08 A | 2006-04-28 | 10% | 248.4d? | 2005-04-08 | 2006-04-28 | 276d? | 176d | finish no earlier than 2006-04-28 | G1 | 2208h | 220.8h | Rel-7 | Paolo |  | SCSAGB-RRM | Gunnar Hedby, Ericsson | gunnar.hedby@ericsson.com |
| 170 | 60.2 | Radio Channel Support |  | 276d? | 2005-04-08 A | 2006-04-28 | 10% | 248.4d? | 2005-04-08 | 2006-04-28 | 276d? | 176d | finish no earlier than 2006-04-28 | G2 | 2208h | 220.8h | Rel-7 | Gert |  | SCSAGB-RCHS | Gunnar Hedby, Ericsson | gunnar.hedby@ericsson.com |
| 171 | 60.3 | Modifications to FLO |  | 276d? | 2005-04-08 A | 2006-04-28 | 10% | 248.4d? | 2005-04-08 | 2006-04-28 | 276d? | 176d | finish no earlier than 2006-04-28 | G2 | 2208h | 220.8h | Rel-7 | Gert |  | SCSAGB-FLO | Gunnar Hedby, Ericsson | gunnar.hedby@ericsson.com |
| 172 | 61 | **Addition of new frequency band to GSM (T-GSM810)** |  | 106d? | 2005-04-08 | 2005-09-02 |  |  | 2005-04-08 | 2005-09-02 | 106d? | 347d |  | GP | 2992h |  | Rel-7 | Paolo |  | T-GSM810 | Chen De, Huawei | chende@huawei.com |
| 173 | 61.1 | Changes to core specification |  | 56d? | 2005-04-08 | 2005-06-24 |  |  | 2005-04-08 | 2005-06-24 | 56d? | 397d | finish no earlier than 2005-06-24 | GP | 448h |  | Rel-7 | Paolo |  | T-GSM810-Core | Chen De, Huawei | chende@huawei.com |
| 174 | 61.2 | Changes to MS testing specification |  | 106d? | 2005-04-08 | 2005-09-02 |  |  | 2005-04-08 | 2005-09-02 | 106d? | 347d | finish no earlier than 2005-09-02 | G3 | 848h |  | Rel-7 | Stoyan |  | T-GSM810-Mstest | Chen De, Huawei | chende@huawei.com |
| 175 | 61.3 | Changes to BTS testing specification |  | 106d? | 2005-04-08 | 2005-09-02 |  |  | 2005-04-08 | 2005-09-02 | 106d? | 347d | finish no earlier than 2005-09-02 | G1 | 848h |  | Rel-7 | Paolo |  | T-GSM810-BTStest | Chen De, Huawei | chende@huawei.com |
| 176 | 62 | **Handover of dedicated and shared resources while in dual transfer mode** |  | 421d? | 2005-04-11 | 2006-11-17 |  |  | 2005-04-08 | 2006-11-17 | 421d? | 31d |  | GP | 10104h |  | Rel-7 | Paolo |  | HO-DSRDTM | Rami Vaittinen, Nokia | rami.vaittinen@nokia.com |
| 177 | 62.1 | MS conformance testing |  | 421d? | 2005-04-11 | 2006-11-17 |  |  | 2005-04-08 | 2006-11-17 | 421d? | 31d | finish no earlier than 2006-11-17 | G3 | 3368h |  | Rel-7 | Stoyan |  | HO-DSRDTM-MStest | Rami Vaittinen, Nokia | rami.vaittinen@nokia.com |
| 178 | 62.2 | BTS conformance testing |  | 421d? | 2005-04-11 | 2006-11-17 |  |  | 2005-04-08 | 2006-11-17 | 421d? | 31d | finish no earlier than 2006-11-17 | G1 | 3368h |  | Rel-7 | Paolo |  | HO-DSRDTM-BTStest | Rami Vaittinen, Nokia | rami.vaittinen@nokia.com |
| 179 | 63 | Future GERAN Evolution |  | 156d? | 2005-04-08 A | 2005-11-11 | 5% | 148.2d? | 2005-04-08 | 2005-11-11 | 156d? | 297d | finish no earlier than 2005-11-11 | GP | 1248h | 62.4h | Rel-7 | Paolo |  | FGE | Eddie Riddington, Nokia Corporation | eddie.riddington@nokia.com |
| 180 | 64 | 3G-324M Video Telephony Call Setup Times Improvements |  | 391d? | 2005-06-09 | 2006-12-06 |  |  | 2005-06-08 | 2006-12-06 | 391d? | 18d | finish no earlier than 2006-12-06 | S4 | 3128h |  | Rel-7 | Paolo |  | VTCSTI | Edward Hall (Vodafone) | edward.hall@vodafone.co.uk |
| 181 | 65 | Personal Network (PN) and Personal Area Network (PAN) |  | 101.2d? | 2005-07-11 | 2005-12-08 |  |  | 2005-07-11 | 2005-12-08 | 101.2d? | 278d | finish no earlier than 2005-12-08 | S1 | 809.6h |  | Rel-7 | Mike |  | PNPAN | Armin Toepfer, Vodafone | armin.toepfer@vodafone.com |
| 182 | 66 | Multimedia Telephony Capabilities for IMS |  | 101.2d? | 2005-07-11 | 2005-12-08 |  |  | 2005-07-11 | 2005-12-08 | 101.2d? | 278d | finish no earlier than 2005-12-08 | S1 | 809.6h |  | Rel-7 | Mike |  | MITE | Peter Bleckert, Ericsson | peter.bleckert @ericsson.com |
| 183 | 67 | Transferring of emergency Call data |  | 109d? | 2005-07-11 | 2005-12-08 |  |  | 2005-07-11 | 2005-12-08 | 109d? | 278d | finish no earlier than 2005-12-08 | S1 | 872h |  | Rel-7 | Mike |  | eCALL | Steve Vardy, (Motorola S.A.S) | steven.vardy@motorola.com |
| 184 | 68 | MBMS Enhancements |  | 109d? | 2005-07-11 | 2005-12-08 |  |  | 2005-07-11 | 2005-12-08 | 109d? | 278d | finish no earlier than 2005-12-08 | S1 | 872h |  | Rel-7 | Mike |  | MBMSE | Liu Hong, China Mobile | liuhongyfw@chinamobile.com |
| 185 | 69 | NEW!! FS on Continuous connectivity for packet data users |  | 132d? | 2005-03-15 | 2005-09-15 |  |  | 2005-03-15 | 2005-09-15 | 132d? | 339d | finish no earlier than 2005-09-15 | R1 | 1056h |  | Rel-7 | Cesar | TSG | RANFS-cont-packet | Joerg Gustrau | joerg.gustrau@siemens.com |
| 186 | 70 | NEW!! FS onUTRA Tower Mounted Amplifier (FDD) |  | 195d? | 2005-06-16 | 2006-03-15 |  |  | 2005-06-15 | 2006-03-15 | 195d? | 209d | finish no earlier than 2006-03-15 | R4 | 1560h |  | Rel-7 | Cesar | TSG | RANFS-TMA | Klas Sjerling | Klas.Sjerling@ericsson.com |
| 187 | 71 | Identification of Communication Services in IMS |  | 321d? | 2005-05-02 A | 2006-07-21 | 5% | 304.95d? | 2005-05-02 | 2006-07-24 | 321d? | 116d | start no earlier than 2005-05-02 | S2 | 2568h | 128.4h | Rel-7 | Maurice |  | ServID | Stephen Terrill, Ericsson | stephen.terrill@ericsson.com |
| 188 | 72 | TR for ICS |  | 232d? | 2005-05-02 A | 2006-03-20 | 20% | 185.6d? |  |  |  | 205d | finish no earlier than 2006-03-20 | S2 | 1856h | 371.2h | Rel-7 |  |  | ServID |  |  |
| 189 | 73 | Stage 2 for ICS |  | 56d? | 2006-03-27 | 2006-06-12 |  |  |  |  |  | 145d | finish no earlier than 2006-06-12 | S2 | 448h |  | Rel-7 |  |  | ServID |  |  |
| 190 | 74 | FS on enhancement of radio performance for VoIMS |  | 321d? | 2005-05-02 A | 2006-07-21 | 5% | 304.95d? | 2005-05-02 | 2006-07-24 | 321d? | 116d | start no earlier than 2005-05-02 | S2 | 2568h | 128.4h | Rel-7 | Maurice |  | VoIMS | Laurence Lautier, Nortel Networks | lautierl@nortel.com |
| 191 | 75 | (check Release) Improved support of IMS Realtime Services using HSDPA/HSUPA |  | 197d? | 2005-03-15 A | 2005-12-14 | 15% | 167.45d? | 2005-03-15 | 2005-12-14 | 197d? | 274d | start no earlier than 2005-03-15 | R2 | 1576h | 236.4h | Rel-7 | Cesar | TSG | RInImp-IMSRealTime | Don Zelmer | don.zelmer@CINGULAR.COM |
| 192 | 76 | Performance Characterization of VoIMS over HSDPA\EUL channels20028 |  | 262d? | 2005-03-15 A | 2006-03-15 | 5% | 248.9d? | 2005-03-15 | 2006-03-15 | 262d? | 208d | finish no earlier than 2006-03-15 | S4 | 2096h | 104.8h | Rel-7 | Paolo | TSG | PCVoIMS | Dimitris Vasilaras (Lucent Technologies) | dvasilaras@lucent.com |

Notes:
- 161: Created at TSG#27 by A. Sultan because of the move to Rel-7 of "Common Objects".
- 162: No progress in CN4#26. This have to be moved to Rel-7. It was deleted from WID / Text3: 24.241
- 164: This is a generic feature without particular end date
- 165: WID approved SA#26. Record created after SA#27
- 166: WID approved SA#26, Dependant on Funding Availability. Record created after SA#27 / Text3: 33.102
- 172: Text3: 45.005, 45.050, 24.008, 45.008, 45.001, 43.022, 43.030, 44.018, 44.060, 51.010-1, 51.021
- 173: Text3: 45.005, 45.050, 24.008, 45.008, 45.001, 43.022, 43.030, 44.018, 44.060
- 174: Text3: 51010-1
- 175: Text3: 51021
- 176: Not started / Text3: 43.055, 44.018, 44.060
- 177: Not started / Text3: 51010-1
- 178: Not started
- 179: FS started
- 180: Conditionally, in the event Phase 2 is needed, end is Dec.06 / Text3: 26.abc
- 187: WID approved SA#28 / Text3: 23.228, 23.218, 23.125
- 190: WID approved SA#28
- 192: Started / Text3: 26.935
